# ساخت ابر خازن الکتروشیمیایی بر پایه ترکیبات نانومتخلخل کربنی- فاز یک

Schedule from MS Project, 2020-06-21 to 2021-10-22, status date 2021-05-21, A marks actual dates.

## Calendars

- Standard: Mon-Sun 08:00-16:00.

## Schedule

| ID | WBS | Task | Duration | Start | Finish | Predecessors | Complete | Remaining | Total slack | Free slack | Constraint | تاریخ شروع شمسی | تاریخ پایان شمسی |
| --- | --- | --- | --- | --- | --- | --- | --- | --- | --- | --- | --- | --- | --- |
| 1 | 1 | **فاز مطالعاتی** | 90d | 2020-06-21 A | 2020-09-18 A |  | 100% |  |  |  |  | 99/4/1 | 99/6/28 |
| 2 | 1.1 | **جمع آوری اطلاعات** | 30d | 2020-06-21 A | 2020-07-20 A |  | 100% |  |  |  |  | 99/4/1 | 99/4/30 |
| 3 | 1.1.1 | مطالعات کتابخانه ای | 30d | 2020-06-21 A | 2020-07-20 A |  | 100% |  |  |  |  | 99/4/1 | 99/4/30 |
| 4 | 1.1.2 | جمع آوری سوابق اجرای طرح | 30d | 2020-06-21 A | 2020-07-20 A | 3SS | 100% |  |  |  |  | 99/4/1 | 99/4/30 |
| 5 | 1.2 | **تکمیل مطالعات** | 60d | 2020-06-21 A | 2020-08-19 A |  | 100% |  |  |  |  | 99/4/1 | 99/5/29 |
| 6 | 1.2.1 | بررسی اطلاعات و استخراج روش های مناسب سنتز مواد | 30d | 2020-06-21 A | 2020-07-20 A | 4SS | 100% |  |  |  |  | 99/4/1 | 99/4/30 |
| 7 | 1.2.2 | بررسی استانداردها و روش های مناسب سنتز مواد | 30d | 2020-07-21 A | 2020-08-19 A | 6 | 100% |  |  |  |  | 99/4/31 | 99/5/29 |
| 8 | 1.3 | تهیه گزارش فاز مطالعاتی | 60d | 2020-07-21 A | 2020-09-18 A | 7SS | 100% |  |  |  |  | 99/4/31 | 99/6/28 |
| 9 | 2 | **فاز آزمایشگاهی** | 368d | 2020-08-20 A | 2021-08-22 |  | 45% | 204.12d | 61d |  |  | 99/5/30 | 100/5/31 |
| 10 | 2.1 | **خرید مواد و تجهیزات** | 337d | 2020-08-20 A | 2021-07-22 |  | 59% | 137.13d | 92d |  |  | 99/5/30 | 100/4/31 |
| 11 | 2.1.1 | استعلام قیمت و سفارش خرید مواد | 90d | 2020-08-20 A | 2020-11-17 A | 8SS+30d | 100% |  |  |  |  | 99/5/30 | 99/8/27 |
| 12 | 2.1.2 | **استعلام قیمت و سفارش خرید تجهیزات** | 337d | 2020-08-20 A | 2021-07-22 |  | 57% | 144.26d | 92d |  |  | 99/5/30 | 100/4/31 |
| 13 | 2.1.2.1 | کوره | 90d | 2020-08-20 A | 2020-11-17 A | 11SS | 100% |  |  |  |  | 99/5/30 | 99/8/27 |
| 14 | 2.1.2.2 | آون | 90d | 2020-08-20 A | 2020-11-17 A | 13SS | 100% |  |  |  |  | 99/5/30 | 99/8/27 |
| 15 | 2.1.2.3 | تستر شارژ و دشارژ | 337d | 2020-08-20 A | 2021-07-22 | 14SS | 27% | 247d | 92d | 0d | finish no earlier than 2021-07-22 | 99/5/30 | 100/4/31 |
| 16 | 2.1.2.4 | ژنراتور نیتروزن | 337d | 2020-08-20 A | 2021-07-22 | 15SS | 27% | 247d | 92d |  | finish no earlier than 2021-07-22 | 99/5/30 | 100/4/31 |
| 17 | 2.1.2.5 | سیستم فیلتراسیون | 90d | 2020-08-20 A | 2020-11-17 A | 16SS | 100% |  |  |  |  | 99/5/30 | 99/8/27 |
| 18 | 2.1.2.6 | کارل فیشر | 90d | 2020-08-20 A | 2020-11-17 A | 17SS | 100% |  |  |  |  | 99/5/30 | 99/8/27 |
| 19 | 2.1.2.7 | آب مقطر | 90d | 2020-08-20 A | 2020-11-17 A | 18SS | 100% |  |  |  |  | 99/5/30 | 99/8/27 |
| 20 | 2.1.2.8 | پتانسیو استات گالوانواستات | 90d | 2020-08-20 A | 2020-11-17 A | 19SS | 100% |  |  |  |  | 99/5/30 | 99/8/27 |
| 21 | 2.1.2.9 | حمام التراسونیک | 90d | 2020-08-20 A | 2020-11-17 A | 20SS | 100% |  |  |  |  | 99/5/30 | 99/8/27 |
| 22 | 2.1.2.10 | پمپ خلا | 90d | 2020-08-20 A | 2020-11-17 A | 21SS | 100% |  |  |  |  | 99/5/30 | 99/8/27 |
| 23 | 2.1.2.11 | هود گلاوباکس | 337d | 2020-08-20 A | 2021-07-22 | 22SS | 27% | 247d | 92d |  | finish no earlier than 2021-07-22 | 99/5/30 | 100/4/31 |
| 24 | 2.2 | **بهینه سازی نمونه آزمایشگاهی** | 308d | 2020-10-19 A | 2021-08-22 |  | 49% | 156.52d | 61d |  |  | 99/7/28 | 100/5/31 |
| 25 | 2.2.1 | **سنتز نانو مواد کربنی** | 60d | 2020-10-19 A | 2020-12-17 A |  | 100% |  |  |  |  | 99/7/28 | 99/9/27 |
| 26 | 2.2.1.1 | سنتز نمونه آزمایشگاهی | 60d | 2020-10-19 A | 2020-12-17 A | 23SS+60d | 100% |  |  |  |  | 99/7/28 | 99/9/27 |
| 27 | 2.2.1.2 | آزمون های تعیین ساختار با استفاده از خرید خدمت | 60d | 2020-10-19 A | 2020-12-17 A | 26SS | 100% |  |  |  |  | 99/7/28 | 99/9/27 |
| 28 | 2.2.1.3 | آزمون های الکتروشیمیایی عملکردی | 60d | 2020-10-19 A | 2020-12-17 A | 27SS | 100% |  |  |  |  | 99/7/28 | 99/9/27 |

| ID | WBS | Task | Duration | Start | Finish | Predecessors | Complete | Remaining | Total slack | Free slack | Constraint | تاریخ شروع شمسی | تاریخ پایان شمسی |
| --- | --- | --- | --- | --- | --- | --- | --- | --- | --- | --- | --- | --- | --- |
| 29 | 2.2.2 | **انتخاب الکترولیت و حلال** | 308d | 2020-10-19 A | 2021-08-22 |  | 19% | 248d | 61d |  |  | 99/7/28 | 100/5/31 |
| 30 | 2.2.2.1 | آزمون های الکتروشیمیایی عملکردی | 308d | 2020-10-19 A | 2021-08-22 | 28SS | 19% | 248d | 61d | 60d | finish no earlier than 2021-08-22 | 99/7/28 | 100/5/31 |
| 31 | 2.3 | **سنتز ماده کربنی در مقیاس بالاتر** | 248d | 2020-12-18 A | 2021-08-22 |  | 12% | 218d | 61d |  |  | 99/9/28 | 100/5/31 |
| 32 | 2.3.1 | سنتز نمونه کربنی | 248d | 2020-12-18 A | 2021-08-22 | 30SS | 12% | 218d | 61d | 0d | finish no earlier than 2021-08-22 | 99/9/28 | 100/5/31 |
| 33 | 2.3.2 | آزمون های تعیین ساختار با استفاده از خرید خدمت | 248d | 2020-12-18 A | 2021-08-22 | 32SS | 12% | 218d | 61d | 0d | finish no earlier than 2021-08-22 | 99/9/28 | 100/5/31 |
| 34 | 2.3.3 | آزمون های الکتروشمیایی عملکردی | 248d | 2020-12-18 A | 2021-08-22 | 33SS | 12% | 218d | 0d |  | finish no earlier than 2021-08-22 | 99/9/28 | 100/5/31 |
| 35 | 2.4 | گزارش فاز آزمایشگاهی | 248d | 2020-12-18 A | 2021-08-22 | 32SS | 24% | 188d | 61d | 0d | finish no earlier than 2021-08-22 | 99/9/28 | 100/5/31 |
| 36 | 3 | **فاز طراحی و ساخت** | 279d | 2021-01-17 A | 2021-10-22 |  | 70% | 84.61d | 0d |  |  | 99/10/28 | 100/7/30 |
| 37 | 3.1 | **طراحی و ساخت ابرخازن با ظرفیت 20 فارادی و ولتاژ 7و2 ولت** | 279d | 2021-01-17 A | 2021-10-22 |  | 55% | 124.78d | 0d |  |  | 99/10/28 | 100/7/30 |
| 38 | 3.1.1 | طراحی | 61d | 2021-01-17 A | 2021-09-22 | 35SS+30d, 34 | 49% | 31d | 0d |  | finish no earlier than 2021-09-22 | 99/10/28 | 100/6/31 |
| 39 | 3.1.2 | ساخت | 249d | 2021-02-16 A | 2021-10-22 | 38 | 88% | 30d | 0d |  | finish no earlier than 2021-10-22 | 99/11/28 | 100/7/30 |
| 40 | 3.1.3 | آزمون های عملکردی | 249d | 2021-02-16 A | 2021-10-22 | 39SS | 24% | 189d | 0d |  | finish no earlier than 2021-10-22 | 99/11/28 | 100/7/30 |
| 41 | 3.2 | **طراحی و ساخت ابرخازن با ظرفیت 50 فارادی و ولتاژ 7و2 ولت** | 61d | 2021-08-23 A | 2021-10-22 |  | 99% | 0.67d | 0d |  |  | 100/6/1 | 100/7/30 |
| 42 | 3.2.1 | طراحی | 31d | 2021-08-23 A | 2021-09-22 | 38SS | 97% | 1d | 30d | 0d | finish no earlier than 2021-09-22 | 100/6/1 | 100/6/31 |
| 43 | 3.2.2 | ساخت | 30d | 2021-09-23 A | 2021-10-22 A | 42 | 100% |  |  |  |  | 100/7/1 | 100/7/30 |
| 44 | 3.2.3 | آزمون های عملکردی | 30d | 2021-09-23 A | 2021-10-22 A | 43SS | 100% |  |  |  | finish no earlier than 2021-10-22 | 100/7/1 | 100/7/30 |
| 45 | 3.3 | **طراحی و ساخت ابرخازن با ظرفیت 360 فارادی و ولتاژ 7و2 ولت** | 61d | 2021-08-23 A | 2021-10-22 |  | 99% | 0.67d | 0d |  |  | 100/6/1 | 100/7/30 |
| 46 | 3.3.1 | طراحی | 31d | 2021-08-23 A | 2021-09-22 | 42SS | 97% | 1d | 30d |  | finish no earlier than 2021-09-22 | 100/6/1 | 100/6/31 |
| 47 | 3.3.2 | ساخت | 30d | 2021-09-23 A | 2021-10-22 A | 46 | 100% |  |  |  |  | 100/7/1 | 100/7/30 |
| 48 | 3.3.3 | آزمون های عملکردی | 30d | 2021-09-23 A | 2021-10-22 A | 47SS | 100% |  |  |  |  | 100/7/1 | 100/7/30 |
| 49 | 3.4 | **برآورد اقتصادی** | 30d | 2021-09-23 A | 2021-10-22 A |  | 100% |  |  |  |  | 100/7/1 | 100/7/30 |
| 50 | 3.4.1 | تعیین قیمت تمام شده | 30d | 2021-09-23 A | 2021-10-22 A | 48SS+30d | 100% |  |  |  |  | 100/7/1 | 100/7/30 |
| 51 | 3.4.2 | برآورد هزینه برای ساخت واحد نیمه صنعتی | 30d | 2021-09-23 A | 2021-10-22 A | 50SS | 100% |  |  |  | finish no earlier than 2021-05-16 | 100/7/1 | 100/7/30 |
| 52 | 3.5 | گزارش نهایی | 30d | 2021-09-23 A | 2021-10-22 A | 51SS+30d, 40, 44 | 100% |  |  |  | finish no earlier than 2021-10-22 | 100/7/1 | 100/7/30 |
